# 2011-03-14_workplan_WP2_v1_TR

Schedule from MS Project, 2010-11-01 to 2012-08-24.
FZK

## Calendars

- Standard: Mon-Fri 08:00-12:00, 13:00-17:00; Sat-Sun off.

## Resources

| Resource |
| --- |
| T. Rolo |
| T. Weiss |
| T. Farago |
| Ext. Comp. Optics |
| Ext. Comp. Mechanics |
| ANKA Tech. pool |
| ANKA IT pool |

## Schedule

| ID | WBS | Task | Type | Duration | Start | Finish | Predecessors | Total slack | Free slack | Constraint | Resources | Work |
| --- | --- | --- | --- | --- | --- | --- | --- | --- | --- | --- | --- | --- |
| 1 | 1 | **WP2.1** |  | 475d? | 2010-11-01 | 2012-08-24 |  | 0d |  |  |  | 3000h |
| 2 | 1.1 | mechanical concept |  | 120d? | 2010-11-01 | 2011-04-15 |  | 0d |  | start no earlier than 2010-11-01 | T. Rolo | 960h |
| 3 | 1.2 | Specifications joined | milestone | 0d | 2011-04-15 | 2011-04-15 | 2 | 0d |  |  | T. Rolo |  |
| 4 | 1.3 | control interface concept |  | 65d? | 2011-02-14 | 2011-05-13 |  | 335d |  | finish no earlier than 2011-05-13 | T. Farago | 520h |
| 5 | 1.4 | discussion with comp. |  | 6mo | 2011-04-18 | 2011-09-30 | 2, 3 | 0d |  |  |  |  |
| 6 | 1.5 | construction |  | 7.5mo | 2011-10-03 | 2012-04-27 | 5 | 0d |  | finish no later than 2012-04-27 | Ext. Comp. Mechanics | 1200h |
| 7 | 1.6 | FAT |  | 1w | 2012-04-30 | 2012-05-04 | 6 | 0d |  |  |  |  |
| 8 | 1.7 | Delivery |  | 1mo | 2012-05-07 | 2012-06-01 | 7 | 0d |  | start no earlier than 2012-04-19 |  |  |
| 9 | 1.8 | Installation |  | 2mo | 2012-06-04 | 2012-07-27 | 8 | 0d |  |  | ANKA Tech. pool | 320h |
| 10 | 1.9 | SAT |  | 1mo | 2012-07-30 | 2012-08-24 | 9 | 0d |  |  |  |  |
| 11 | 2 | **WP2.2** |  | 375d? | 2010-11-01 | 2012-04-06 |  | 70d |  |  |  | 2720h |
| 12 | 2.1 | optical concept |  | 120d? | 2010-11-01 | 2011-04-15 |  | 70d | 0d | finish no earlier than 2011-04-15 | T. Rolo | 960h |
| 13 | 2.2 | mech. Concept |  | 120d? | 2010-11-01 | 2011-04-15 |  | 70d | 0d | start no earlier than 2010-11-01 | T. Rolo | 960h |
| 14 | 2.3 | specifications | milestone | 0d | 2011-04-15 | 2011-04-15 | 13, 12 | 70d | 0d |  |  |  |
| 15 | 2.4 | discussion with company |  | 6mo | 2011-04-18 | 2011-09-30 | 14 | 70d | 0d |  |  |  |
| 16 | 2.5 | construction |  | 4mo | 2011-10-03 | 2012-01-20 | 15 | 70d | 0d | finish no later than 2012-04-27 | Ext. Comp. Optics | 640h |
| 17 | 2.6 | FAT |  | 1w | 2012-01-23 | 2012-01-27 | 16 | 100d | 0d |  |  |  |
| 18 | 2.7 | Delivery |  | 1mo | 2012-01-30 | 2012-02-24 | 17 | 100d | 0d |  |  |  |
| 19 | 2.8 | Installation |  | 1mo | 2012-02-27 | 2012-03-23 | 18 | 100d | 0d |  | ANKA Tech. pool | 160h |
| 20 | 2.9 | SAT |  | 2w | 2012-03-26 | 2012-04-06 | 19 | 100d |  |  |  |  |
| 21 | 3 | **Detector Lab** |  | 30d | 2011-03-14 | 2011-04-22 |  | 350d |  |  |  |  |
| 22 | 3.1 | Installation |  | 2w | 2011-03-14 | 2011-03-25 |  | 350d | 0d |  |  |  |
| 23 | 3.2 | Commisioning |  | 4w | 2011-03-28 | 2011-04-22 | 22 | 350d |  |  |  |  |

Notes:
- 4: Possible Motion platforms: / - A3200 (Aerotech) / - Delta Tau / Software for Image Bemline: / Low level API / communication: UCA, JAIL, WP3 Framework / Integration with rest of beamline components: Tango + Taurus(GUI) + Spock(CLI)
- 5: Possible companies: / - Aerotech / - Micos / -Alio Industries
- 15: Posiible companies: / - Optique Peter / - Elya Solutions / - Swissoptic / - Specialoptics
- 22: Comonents already arrived, has to be coordinated with X-ray part of the lab / Start: 2011-03-14
